# Project Percorso critico giusto Retrovie

Schedule from MS Project, 2019-10-21 to 2020-02-24, costs in €.

## Calendars

- Standard: Mon-Fri 09:00-13:00, 14:00-18:00; Sat-Sun off.

## Resources

| Resource | Rate |
| --- | --- |
| Analista | 30 |
| Analista programmatore | 30 |
| Programmatore 1 | 28 |
| Programmatore 2 | 28 |
| Programmatore work flow | 35 |

## Schedule

| ID | WBS | Task | Type | Duration | Start | Finish | Predecessors | Total slack | Resources | Work | Cost |
| --- | --- | --- | --- | --- | --- | --- | --- | --- | --- | --- | --- |
| 1 | 1 | **Totale** |  | 91d | 2019-10-21 | 2020-02-24 |  | 0d |  | 1008h | 30,128.8 |
| 2 | 1.1 | **Analisi** |  | 39d | 2019-10-21 | 2019-12-12 |  | 0d |  | 331.2h | 9,936 |
| 3 | 1.1.1 | Intervista 1 |  | 2d | 2019-10-21 | 2019-10-22 |  | 6d | Analista [15%] | 2.4h | 72 |
| 4 | 1.1.2 | Intervista 2 | manual | 2d | 2019-10-21 | 2019-10-22 |  |  | Analista [15%] | 2.4h | 72 |
| 5 | 1.1.3 | Intervista 3 | manual | 2d | 2019-10-23 | 2019-10-24 |  |  | Analista [15%] | 2.4h | 72 |
| 6 | 1.1.4 | Intervista 4 | manual | 2d | 2019-10-23 | 2019-10-24 |  |  | Analista [15%] | 2.4h | 72 |
| 7 | 1.1.5 | Intervista 5 | manual | 2d | 2019-10-25 | 2019-10-28 |  |  | Analista [15%] | 2.4h | 72 |
| 8 | 1.1.6 | Intervista 6 | manual | 2d | 2019-10-25 | 2019-10-28 |  |  | Analista [15%] | 2.4h | 72 |
| 9 | 1.1.7 | Intervista 7 | manual | 2d | 2019-10-29 | 2019-10-30 |  |  | Analista [15%] | 2.4h | 72 |
| 10 | 1.1.8 | Intervista 8 | manual | 2d | 2019-10-29 | 2019-10-30 |  |  | Analista [15%] | 2.4h | 72 |
| 11 | 1.1.9 | Revisione Interviste | manual | 30d | 2019-10-31 | 2019-12-11 | 3, 4, 5, 6, 7, 8, 9, 10 |  | Analista [30%]; Analista programmatore | 312h | 9,360 |
| 12 | 1.1.10 | Milestone Requisiti | milestone, manual | 1d | 2019-12-12 | 2019-12-12 | 11 |  |  |  |  |
| 13 | 1.2 | **Progettazione** |  | 13d | 2019-12-13 | 2019-12-31 |  | 0d |  | 144h | 4,560 |
| 14 | 1.2.1 | Definizione Specifiche | manual | 12d | 2019-12-13 | 2019-12-30 | 12 |  | Analista programmatore; Programmatore work flow [50%] | 144h | 4,560 |
| 15 | 1.2.2 | Milestone Specifiche | manual | 1d | 2019-12-31 | 2019-12-31 | 14 |  |  |  |  |
| 16 | 1.3 | **Realizzazione** |  | 35d | 2020-01-01 | 2020-02-18 |  | 0d |  | 468.8h | 13,840.8 |
| 17 | 1.3.1 | **Codifica** |  | 11d | 2020-01-01 | 2020-01-15 |  | 0d |  | 164.8h | 4,816 |
| 18 | 1.3.1.1 | Contabilità | manual | 4d | 2020-01-01 | 2020-01-06 | 15 |  | Programmatore work flow [12%]; Programmatore 1 [50%]; Programmatore 2 [50%] | 35.84h | 1,030.4 |
| 19 | 1.3.1.2 | Vendite | manual | 10d | 2020-01-01 | 2020-01-14 | 15, 18FF |  | Programmatore work flow [12%]; Programmatore 1 [25%]; Programmatore 2 [25%] | 49.6h | 1,456 |
| 20 | 1.3.1.3 | Direzione | manual | 8d | 2020-01-03 | 2020-01-14 | 15, 19FF |  | Programmatore work flow [12%]; Programmatore 1 [25%]; Programmatore 2 [25%] | 39.68h | 1,164.8 |
| 21 | 1.3.1.4 | Ufficio fatturazione | manual | 4d | 2020-01-09 | 2020-01-14 | 15, 20FF |  | Programmatore work flow [12%]; Programmatore 1 [25%]; Programmatore 2 [25%] | 19.84h | 582.4 |
| 22 | 1.3.1.5 | Ufficio Spedizioni | manual | 4d | 2020-01-09 | 2020-01-14 | 15, 21FF |  | Programmatore work flow [12%]; Programmatore 1 [25%]; Programmatore 2 [25%] | 19.84h | 582.4 |
| 23 | 1.3.1.6 | Milestone Codifica | manual | 1d | 2020-01-15 | 2020-01-15 | 18, 19, 20, 21, 22 |  |  |  |  |
| 24 | 1.3.2 | Test Prototipo | manual | 13d | 2020-01-16 | 2020-02-03 | 23 |  | Programmatore 1; Programmatore 2; Programmatore work flow [50%] | 260h | 7,644 |
| 25 | 1.3.3 | Milestone fine prototipo | manual | 1d | 2020-02-04 | 2020-02-04 | 24 |  |  |  |  |
| 26 | 1.3.4 | meeting | manual | 1d | 2020-02-05 | 2020-02-05 | 25 |  | Analista [10%]; Analista programmatore [10%]; Programmatore 1 [10%]; Programmatore 2 [10%]; Programmatore work flow [10%] | 4h | 120.8 |
| 27 | 1.3.5 | Ripianificazione | manual | 3d | 2020-02-06 | 2020-02-10 | 26 |  | Analista [30%]; Programmatore work flow [50%] | 19.2h | 636 |
| 28 | 1.3.6 | Validazione | manual | 2d | 2020-02-11 | 2020-02-12 | 27 |  | Analista [30%] | 4.8h | 144 |
| 29 | 1.3.7 | Milestone Validazione | manual | 1d | 2020-02-13 | 2020-02-13 | 28 |  |  |  |  |
| 30 | 1.3.8 | Formazione Utenti | manual | 2d | 2020-02-14 | 2020-02-17 | 29 |  | Analista programmatore | 16h | 480 |
| 31 | 1.3.9 | Milestone Formazione | manual | 1d | 2020-02-18 | 2020-02-18 | 30 |  |  |  |  |
| 32 | 1.4 | Produzione | manual | 4d | 2020-02-19 | 2020-02-24 | 31 |  | Programmatore 2; Programmatore 1 | 64h | 1,792 |
